# 2008 Annual Report

Schedule from MS Project, 2017-08-04 to 2017-09-28, status date 2017-09-28, costs in $, A marks actual dates.
DCF
The CFO must review all materials before finalizing the report.

## Calendars

- Standard: Mon-Fri 07:00-11:00, 12:00-16:00; Sat-Sun off.

## Resources

| Resource | Group | Rate |
| --- | --- | --- |
| Office Temp | office staff | 12 |
| Editor |  | 30 |
| Office Manager | management | 21.63 |
| Vice President | management | 36.06 |
| Administrative Assistant |  | 20 |
| President | management | 43.27 |
| Chief Financial Officer | management | 38.46 |
| Accounting Assistant | office staff | 15 |
| Accountant | office staff | 40 |
| Layout Coordinator |  | 25 |
| Marketing Vice President | management | 33.65 |

## Schedule

| ID | WBS | Task | Type | Duration | Start | Finish | Predecessors | Complete | Remaining | Total slack | Constraint | Resources | Work | Actual work | Cost | Actual cost |
| --- | --- | --- | --- | --- | --- | --- | --- | --- | --- | --- | --- | --- | --- | --- | --- | --- |
| 1 | 1 | **Annual Financial Report** |  | 39.38d | 2017-08-04 A | 2017-09-28 |  | 44% | 22.2d | 0d |  |  | 634h | 302h | 16,440.92 | 8,108.46 |
| 2 | 1.1 | **Initial Planning** |  | 3d | 2017-08-04 A | 2017-08-08 A |  | 100% |  |  |  |  | 72h | 72h | 1,719.23 | 1,719.23 |
| 3 | 1.1.1 | Outline report articles |  | 3d | 2017-08-04 A | 2017-08-08 A |  | 100% |  |  |  | Office Manager; Administrative Assistant; Editor | 72h | 72h | 1,719.23 | 1,719.23 |
| 4 | 1.2 | **Interview Management** |  | 3.5d | 2017-08-07 A | 2017-08-10 A |  | 100% |  |  |  |  | 32h | 32h | 1,085.77 | 1,085.77 |
| 5 | 1.2.1 | President |  | 0.5d | 2017-08-07 A | 2017-08-07 A | 3 | 100% |  |  |  | Editor; President | 8h | 8h | 293.08 | 293.08 |
| 6 | 1.2.2 | Vice President |  | 0.5d | 2017-08-07 A | 2017-08-07 A | 5 | 100% |  |  |  | Editor; Vice President | 8h | 8h | 264.23 | 264.23 |
| 7 | 1.2.3 | Marketing VP |  | 0.5d | 2017-08-10 A | 2017-08-10 A | 6 | 100% |  |  |  | Editor; Marketing Vice President | 8h | 8h | 254.62 | 254.62 |
| 8 | 1.2.4 | Chief Financial Officer |  | 0.5d | 2017-08-08 A | 2017-08-08 A | 7 | 100% |  |  |  | Editor; Chief Financial Officer | 8h | 8h | 273.85 | 273.85 |
| 9 | 1.3 | **Assemble Financial Reports** |  | 13d | 2017-08-07 A | 2017-08-24 |  | 94% | 0.79d | 25.38d |  |  | 206h | 198h | 5,783.46 | 5,303.46 |
| 10 | 1.3.1 | Gather financial data |  | 3.38d | 2017-08-07 A | 2017-08-10 A | 3 | 100% |  |  |  | Administrative Assistant [200%]; Accounting Assistant; Accountant | 63h | 63h | 1,665 | 1,665 |
| 11 | 1.3.2 | Format reports |  | 2d | 2017-08-08 A | 2017-08-09 A | 10FS-2d | 100% |  |  |  | Editor; Layout Coordinator | 32h | 32h | 880 | 880 |
| 12 | 1.3.3 | Compile data reference report |  | 1d | 2017-08-14 A | 2017-08-14 A | 11 | 100% |  |  |  | Administrative Assistant | 8h | 8h | 160 | 160 |
| 13 | 1.3.4 | Create graphics and charts |  | 3.12d | 2017-08-14 A | 2017-08-16 A | 12SS | 100% |  |  |  | Editor; Office Temp; Layout Coordinator | 47h | 47h | 1,060 | 1,060 |
| 14 | 1.3.5 | Review by CFO |  | 5d | 2017-08-14 A | 2017-08-18 A | 13 | 100% |  |  |  | Chief Financial Officer | 40h | 40h | 1,538.46 | 1,538.46 |
| 15 | 1.3.6 | Edit |  | 2d | 2017-08-21 A | 2017-08-22 | 14 | 50% | 1d | 26.38d |  | Editor | 16h | 8h | 480 |  |
| 16 | 1.3.7 | Final approval | milestone | 0d | 2017-08-24 | 2017-08-24 |  |  |  | 0d | start no earlier than 2017-08-24 |  |  |  |  |  |
| 17 | 1.4 | **Write Articles** |  | 10d | 2017-08-24 | 2017-09-06 |  |  |  | 0d |  |  | 152h |  | 4,170.77 |  |
| 18 | 1.4.1 | Write first draft |  | 3d | 2017-08-24 | 2017-08-28 | 16 |  |  | 0d |  | Editor; Office Manager | 48h |  | 1,239.23 |  |
| 19 | 1.4.2 | Management review |  | 5d | 2017-08-29 | 2017-09-04 | 18 |  |  | 0d | as late as possible | Office Manager; Marketing Vice President | 80h |  | 2,211.54 |  |
| 20 | 1.4.3 | Edit |  | 3d | 2017-09-04 | 2017-09-06 | 19FS-1d |  |  | 0d |  | Editor | 24h |  | 720 |  |
| 21 | 1.4.4 | Final text approval | milestone | 0d | 2017-09-06 | 2017-09-06 | 20 |  |  | 0d |  |  |  |  |  |  |
| 22 | 1.5 | **Prepare Final Materials** |  | 8.5d | 2017-09-07 | 2017-09-19 |  |  |  | 0d |  |  | 132h |  | 3,137.69 |  |
| 23 | 1.5.1 | Final layout |  | 3d | 2017-09-07 | 2017-09-11 | 21 |  |  | 0d |  | Administrative Assistant; Layout Coordinator | 48h |  | 1,080 |  |
| 24 | 1.5.2 | Final proof |  | 3d | 2017-09-12 | 2017-09-14 | 23 |  |  | 0d |  | Office Manager; Layout Coordinator | 48h |  | 1,119.23 |  |
| 25 | 1.5.3 | Copy reports |  | 2.5d | 2017-09-15 | 2017-09-19 | 24 |  |  | 0d |  | Administrative Assistant | 20h |  | 400 |  |
| 26 | 1.5.4 | Write cover letter |  | 2d | 2017-09-15 | 2017-09-19 | 25FF |  |  | 0d |  | Marketing Vice President | 16h |  | 538.46 |  |

Notes:
- 13: Due to server problems there was a 1 day delay in work on graphics and charts.

| ID | WBS | Task | Type | Duration | Start | Finish | Predecessors | Total slack | Constraint | Resources | Work | Cost |
| --- | --- | --- | --- | --- | --- | --- | --- | --- | --- | --- | --- | --- |
| 27 | 1.6 | **Distribute Reports** |  | 6.88d | 2017-09-19 | 2017-09-28 |  | 0d |  |  | 40h | 544 |
| 28 | 1.6.1 | Order envelopes/paper stock |  | 1d | 2017-09-19 | 2017-09-20 | 26 | 0d |  | Administrative Assistant | 8h | 160 |
| 29 | 1.6.2 | Print cover letters/envelopes |  | 2d | 2017-09-25 | 2017-09-27 | 28FS+3d | 0d |  | Office Temp | 16h | 192 |
| 30 | 1.6.3 | Stuff report packets |  | 1d | 2017-09-27 | 2017-09-28 | 29 | 0d |  | Office Temp [200%] | 16h | 192 |
| 31 | 1.6.4 | Report packets sent | milestone | 0d | 2017-09-28 | 2017-09-28 | 30 | 0d | as late as possible |  |  |  |
