# Office Remodel

Schedule from MS Project, 2017-01-04 to 2017-07-20, costs in $, A marks actual dates.
Workspace
DCF

## Calendars

- Standard: Mon-Fri 08:00-12:00, 13:00-17:00; Sat-Sun off.

## Resources

| Resource | Group | Rate | Notes |
| --- | --- | --- | --- |
| Vice President | management | 38.46 |  |
| Office Manager | management | 25 |  |
| Administrative Assistant | office staff | 14.42 |  |
| Operations Manager | management | 21.63 |  |
| Space Planner | contract | 40 |  |
| Maintenance | maintenance | 16 | The cost rate table B is for construction cleaning tasks. |
| Contractor | contract |  |  |
| Mover | contract | 25 |  |
| Electrician | contract |  |  |
| Supervisor | office staff | 16.83 |  |

## Schedule

| ID | WBS | Task | Type | Duration | Start | Finish | Predecessors | Complete | Remaining | Baseline start | Baseline finish | Baseline duration | Total slack | Free slack | Constraint | Resources | Work | Actual work | Cost | Baseline cost | Actual cost |
| --- | --- | --- | --- | --- | --- | --- | --- | --- | --- | --- | --- | --- | --- | --- | --- | --- | --- | --- | --- | --- | --- |
| 1 | 1 | **Office Workspace Remodel** |  | 141d | 2017-01-04 A | 2017-07-20 |  | 42% | 81.87d | 2008-01-02 | 2008-03-10 | 48d | 0d |  |  |  | 711h | 304h | 24,780.81 | 24,904.46 | 8,234.04 |
| 2 | 1.1 | **Space planning** |  | 12d | 2017-01-04 A | 2017-01-20 |  | 91% | 1.04d | 2008-01-02 | 2008-01-16 | 11d | 129d |  |  |  | 200h | 192h | 5,793.46 | 5,931.54 | 5,473.46 |
| 3 | 1.1.1 | Interview space planners |  | 0.8w | 2017-01-04 A | 2017-01-09 A |  | 100% |  | 2008-01-02 | 2008-01-07 | 0.8w |  |  | start no earlier than 2017-01-04 | Operations Manager; Office Manager; Vice President [25%] | 72h | 72h | 1,800 | 1,800 | 1,800 |
| 4 | 1.1.2 | Hire space planner |  | 1d | 2017-01-10 A | 2017-01-10 A | 3 | 100% |  | 2008-01-08 | 2008-01-08 | 1d |  |  |  | Vice President; Administrative Assistant | 16h | 16h | 423.08 | 423.08 | 423.08 |
| 5 | 1.1.3 | Meeting w/space planner |  | 2.5d | 2017-01-11 A | 2017-01-13 A | 4 | 100% |  | 2008-01-09 | 2008-01-11 | 3d |  |  |  | Vice President; Administrative Assistant; Operations Manager; Space Planner | 80h | 80h | 2,290.38 | 2,748.46 | 2,290.38 |
| 6 | 1.1.4 | Finalize space plan |  | 4d | 2017-01-16 A | 2017-01-19 | 5 | 75% | 1d | 2008-01-14 | 2008-01-16 | 3d | 129d |  |  | Space Planner | 32h | 24h | 1,280 | 960 | 960 |
| 7 | 1.1.5 | Space plan complete | milestone | 0d | 2017-01-20 A | 2017-01-20 A | 6 | 100% |  | 2008-01-16 | 2008-01-16 | 0d |  |  |  |  |  |  |  |  |  |
| 8 | 1.2 | **Furniture selection** |  | 40d | 2017-01-16 A | 2017-03-13 |  | 85% | 5.85d | 2008-01-14 | 2008-03-10 | 40d | 93d |  |  |  | 69h | 64h | 1,422.12 | 1,407.69 | 1,318.27 |
| 9 | 1.2.1 | Preview furniture selections |  | 2.5d | 2017-01-16 A | 2017-01-18 A | 5 | 100% |  | 2008-01-14 | 2008-01-16 | 2.5d |  |  |  | Office Manager; Operations Manager; Administrative Assistant | 48h | 48h | 976.92 | 976.92 | 976.92 |
| 10 | 1.2.2 | Select new furniture |  | 2d | 2017-01-18 A | 2017-01-20 | 9 | 75% | 0.5d | 2008-01-16 | 2008-01-18 | 2d | 0.38d | 0d |  | Office Manager [75%]; Operations Manager | 16h | 13h | 373.08 | 373.08 | 298.08 |
| 11 | 1.2.3 | Order new furniture |  | 0.62d | 2017-01-20 A | 2017-01-23 | 10 | 60% | 0.25d | 2008-01-18 | 2008-01-18 | 0.5d | 120.38d | 27.38d |  | Administrative Assistant | 5h | 3h | 72.12 | 57.69 | 43.27 |
| 12 | 1.2.4 | Furniture delivered | milestone | 0d | 2017-03-13 | 2017-03-13 | 11FS+1.5w |  |  | 2008-03-10 | 2008-03-10 | 0d | 93d |  | start no earlier than 2017-03-13 |  |  |  |  |  |  |
| 13 | 1.3 | **Remodel workspace** |  | 14d | 2017-01-19 A | 2017-02-07 |  | 21% | 11d | 2008-01-17 | 2008-02-05 | 14d | 116d |  |  |  | 304h | 48h | 14,423.08 | 14,423.08 | 1,442.31 |
| 14 | 1.3.1 | Hire contractor |  | 4d | 2017-01-19 A | 2017-01-24 | 7 | 75% | 1d | 2008-01-17 | 2008-01-22 | 4d | 112d | 0d |  | Vice President; Operations Manager | 64h | 48h | 1,923.08 | 1,923.08 | 1,442.31 |
| 15 | 1.3.2 | Remodel workspace |  | 2w | 2017-01-25 | 2017-02-07 | 14 |  |  | 2008-01-23 | 2008-02-05 | 2w | 112d | 0d |  | Contractor [200%]; Electrician | 240h |  | 12,500 | 12,500 |  |
| 16 | 1.3.3 | Remodel complete | milestone | 0d | 2017-02-07 | 2017-02-07 | 15 |  |  | 2008-02-05 | 2008-02-05 | 0d | 116d |  |  |  |  |  |  |  |  |
| 17 | 1.4 | **New workspace** |  | 129d | 2017-01-19 | 2017-07-18 |  |  |  | 2008-01-17 | 2008-02-11 | 18d | 1d |  |  |  | 138h |  | 3,142.15 | 3,142.15 |  |
| 18 | 1.4.1 | Hire mover |  | 4d | 2017-01-19 | 2017-01-24 | 14SS |  |  | 2008-01-17 | 2008-01-22 | 4d | 119d | 0d |  | Supervisor | 32h |  | 538.46 | 538.46 |  |
| 19 | 1.4.2 | Pack workspace |  | 1d | 2017-01-25 | 2017-01-25 | 18, 14 |  |  | 2008-01-23 | 2008-01-23 | 1d | 119d | 0d |  | Administrative Assistant; Supervisor | 16h |  | 250 | 250 |  |
| 20 | 1.4.3 | Move Equipment |  | 0.5d | 2017-01-25 | 2017-01-25 | 19FF |  |  | 2008-01-23 | 2008-01-23 | 0.5d | 119d | 0d |  | Mover; Operations Manager | 8h |  | 186.54 | 186.54 |  |
| 21 | 1.4.4 | Remove existing furniture |  | 2d | 2017-01-26 | 2017-01-27 | 20 |  |  | 2008-01-24 | 2008-01-25 | 2d | 119d | 118d |  | Mover | 16h |  | 400 | 400 |  |
| 22 | 1.4.5 | Assemble new furniture |  | 2d | 2017-07-13 | 2017-07-14 | 21, 15 |  |  | 2008-02-06 | 2008-02-07 | 2d | 1d | 0d | finish no earlier than 2017-07-14 | Supervisor; Space Planner | 34h |  | 1,069.23 | 1,069.23 |  |
| 23 | 1.4.6 | Return equipment |  | 0.5d | 2017-07-14 | 2017-07-14 | 22FS-0.5d |  |  | 2008-02-07 | 2008-02-07 | 0.5d | 1d | 0d | finish no earlier than 2017-07-14 | Mover; Operations Manager | 8h |  | 186.54 | 186.54 |  |
| 24 | 1.4.7 | Unpack workspace |  | 1d | 2017-07-17 | 2017-07-17 | 23 |  |  | 2008-02-08 | 2008-02-08 | 1d | 1d | 0d |  | Mover; Administrative Assistant | 16h |  | 315.38 | 315.38 |  |
| 25 | 1.4.8 | Workspace final clean |  | 1d | 2017-07-18 | 2017-07-18 | 24 |  |  | 2008-02-11 | 2008-02-11 | 1d | 1d |  |  | Maintenance [50%]; Mover [50%] | 8h |  | 196 | 196 |  |
| 26 | 1.5 | Workspace remodel complete | milestone | 0d | 2017-07-20 | 2017-07-20 | 17 |  |  | 2008-02-11 | 2008-02-11 | 0d | 0d |  | start no earlier than 2017-07-20 |  |  |  |  |  |  |

Notes:
- 11: Allow 1.5 weeks for delivery.
