# Office Remodel

Schedule from MS Project, 2017-01-04 to 2017-07-20, status date 2017-01-23, costs in $, A marks actual dates.
Workspace
DCF

## Calendars

- Standard: Mon-Fri 08:00-12:00, 13:00-17:00; Sat-Sun off.

## Resources

| Resource | Group | Rate | Notes |
| --- | --- | --- | --- |
| Vice President | management | 38.46 |  |
| Office Manager | management | 25 |  |
| Administrative Assistant | office staff | 14.42 |  |
| Operations Manager | management | 21.63 |  |
| Space Planner | contract | 40 |  |
| Maintenance | maintenance | 16 | The cost rate table B is for construction cleaning tasks. |
| Contractor | contract |  |  |
| Mover | contract | 25 |  |
| Electrician | contract |  |  |
| Supervisor | office staff | 16.83 |  |

## Schedule

| ID | WBS | Task | Type | Duration | Start | Finish | Predecessors | Complete | Remaining | Baseline start | Baseline finish | Baseline duration | Total slack | Free slack | Constraint | Resources | Work | Actual work | Cost | Baseline cost | Actual cost |
| --- | --- | --- | --- | --- | --- | --- | --- | --- | --- | --- | --- | --- | --- | --- | --- | --- | --- | --- | --- | --- | --- |
| 1 | 1 | **Office Workspace Remodel** |  | 141d | 2017-01-04 A | 2017-07-20 |  | 51% | 69.09d | 2013-01-02 | 2013-07-18 | 141d | 0d |  |  |  | 717h | 347h | 24,813.5 | 24,813.5 | 9,209.81 |
| 2 | 1.1 | **Space planning** |  | 12d | 2017-01-04 A | 2017-01-19 A |  | 100% |  | 2013-01-02 | 2013-01-17 | 12d |  |  |  |  | 200h | 200h | 5,793.46 | 5,793.46 | 5,793.46 |
| 3 | 1.1.1 | Interview space planners |  | 0.8w | 2017-01-04 A | 2017-01-09 A |  | 100% |  | 2013-01-02 | 2013-01-07 | 0.8w |  |  | start no earlier than 2017-01-04 | Operations Manager; Office Manager; Vice President [25%] | 72h | 72h | 1,800 | 1,800 | 1,800 |
| 4 | 1.1.2 | Hire space planner |  | 1d | 2017-01-10 A | 2017-01-10 A | 3 | 100% |  | 2013-01-08 | 2013-01-08 | 1d |  |  |  | Vice President; Administrative Assistant | 16h | 16h | 423.08 | 423.08 | 423.08 |
| 5 | 1.1.3 | Meeting w/space planner |  | 2.5d | 2017-01-11 A | 2017-01-13 A | 4 | 100% |  | 2013-01-09 | 2013-01-11 | 2.5d |  |  |  | Vice President; Administrative Assistant; Operations Manager; Space Planner | 80h | 80h | 2,290.38 | 2,290.38 | 2,290.38 |
| 6 | 1.1.4 | Finalize space plan |  | 4d | 2017-01-16 A | 2017-01-19 A | 5 | 100% |  | 2013-01-14 | 2013-01-17 | 4d |  |  |  | Space Planner | 32h | 32h | 1,280 | 1,280 | 1,280 |
| 7 | 1.2 | **Furniture selection** |  | 40d | 2017-01-16 A | 2017-03-13 |  | 83% | 6.81d | 2013-01-14 | 2013-03-11 | 40d | 93d |  |  |  | 75h | 67h | 1,508.65 | 1,508.65 | 1,393.27 |
| 8 | 1.2.1 | Preview furniture selections |  | 2.5d | 2017-01-16 A | 2017-01-18 A | 6FS-2d | 100% |  | 2013-01-14 | 2013-01-16 | 2.5d |  |  |  | Office Manager; Operations Manager; Administrative Assistant | 48h | 48h | 976.92 | 976.92 | 976.92 |
| 9 | 1.2.2 | Select new furniture |  | 2d | 2017-01-18 A | 2017-01-20 A | 8 | 100% |  | 2013-01-16 | 2013-01-18 | 2d |  |  |  | Office Manager [75%]; Operations Manager | 16h | 16h | 373.08 | 373.08 | 373.08 |
| 10 | 1.2.3 | Order new furniture |  | 1.38d | 2017-01-20 A | 2017-01-23 | 9 | 27% | 1d | 2013-01-18 | 2013-01-21 | 1.38d | 119.62d | 26.62d |  | Administrative Assistant | 11h | 3h | 158.65 | 158.65 | 43.27 |
| 11 | 1.2.4 | Furniture delivered | milestone | 0d | 2017-03-13 | 2017-03-13 | 10FS+1.5w |  |  | 2013-03-11 | 2013-03-11 | 0d | 93d |  | start no earlier than 2017-03-13 |  |  |  |  |  |  |
| 12 | 1.3 | **Remodel workspace** |  | 13.5d | 2017-01-19 A | 2017-02-07 |  | 22% | 10.5d | 2013-01-17 | 2013-02-05 | 13.5d | 116.5d |  |  |  | 296h | 48h | 14,182.69 | 14,182.69 | 1,442.31 |
| 13 | 1.3.1 | Hire contractor |  | 3.5d | 2017-01-19 A | 2017-01-24 |  | 86% | 0.5d | 2013-01-17 | 2013-01-22 | 3.5d | 1d | 0d |  | Vice President; Operations Manager | 56h | 48h | 1,682.69 | 1,682.69 | 1,442.31 |
| 14 | 1.3.2 | Remodel workspace |  | 2w | 2017-01-24 | 2017-02-07 | 13 |  |  | 2013-01-22 | 2013-02-05 | 2w | 112d | 0d |  | Contractor [200%]; Electrician | 240h |  | 12,500 | 12,500 |  |
| 15 | 1.3.3 | Remodel complete | milestone | 0d | 2017-02-07 | 2017-02-07 | 14 |  |  | 2013-02-05 | 2013-02-05 | 0d | 116.5d |  |  |  |  |  |  |  |  |
| 16 | 1.4 | **New workspace** |  | 129.5d | 2017-01-19 A | 2017-07-19 |  | 23% | 99.62d | 2013-01-17 | 2013-07-17 | 129.5d | 0.5d |  |  |  | 146h | 32h | 3,328.69 | 3,328.69 | 580.77 |
| 17 | 1.4.1 | Hire mover |  | 4d | 2017-01-19 A | 2017-01-24 | 13SS | 50% | 2d | 2013-01-17 | 2013-01-22 | 4d | 0.5d | 0d |  | Supervisor | 32h | 16h | 538.46 | 538.46 | 269.23 |
| 18 | 1.4.2 | Pack workspace |  | 1d | 2017-01-25 A | 2017-01-25 | 17, 13 | 50% | 0.5d | 2013-01-23 | 2013-01-23 | 1d | 118.5d | 0.5d |  | Administrative Assistant; Supervisor | 16h | 8h | 250 | 250 | 125 |
| 19 | 1.4.3 | Move Equipment |  | 1d | 2017-01-25 A | 2017-01-26 | 18FF | 50% | 0.5d | 2013-01-23 | 2013-01-24 | 1d | 118d | 0d |  | Mover; Operations Manager | 16h | 8h | 373.08 | 373.08 | 186.54 |
| 20 | 1.4.4 | Remove existing furniture |  | 2d | 2017-01-26 | 2017-01-30 | 19 |  |  | 2013-01-24 | 2013-01-28 | 2d | 118d | 117.5d |  | Mover | 16h |  | 400 | 400 |  |
| 21 | 1.4.5 | Assemble new furniture |  | 2d | 2017-07-13 | 2017-07-14 | 20, 14 |  |  | 2013-07-11 | 2013-07-12 | 2d | 0.5d | 0d | finish no earlier than 2017-07-14 | Supervisor; Space Planner | 34h |  | 1,069.23 | 1,069.23 |  |
| 22 | 1.4.6 | Return equipment |  | 0.5d | 2017-07-14 | 2017-07-14 | 21FS-0.5d |  |  | 2013-07-12 | 2013-07-12 | 0.5d | 0.5d | 0d | finish no earlier than 2017-07-14 | Mover; Operations Manager | 8h |  | 186.54 | 186.54 |  |
| 23 | 1.4.7 | Unpack workspace |  | 1d | 2017-07-17 | 2017-07-17 | 22 |  |  | 2013-07-15 | 2013-07-15 | 1d | 0.5d | 0d |  | Mover; Administrative Assistant | 16h |  | 315.38 | 315.38 |  |
| 24 | 1.4.8 | Workspace final clean |  | 1.5d | 2017-07-18 | 2017-07-19 | 23 |  |  | 2013-07-16 | 2013-07-17 | 1.5d | 0.5d |  |  | Maintenance [50%]; Mover [50%] | 8h |  | 196 | 196 |  |
| 25 | 1.5 | Workspace remodel complete | milestone | 0d | 2017-07-20 | 2017-07-20 | 16 |  |  | 2013-07-18 | 2013-07-18 | 0d | 0d |  | start no earlier than 2017-07-20 |  |  |  |  |  |  |

Notes:
- 10: Allow 1.5 weeks for delivery.
