# Company Conference

Schedule from MS Project, 2017-06-30 to 2017-08-04, status date 2017-07-31.
Company Conference
DCF

## Calendars

- Standard: Mon-Fri 08:00-12:00, 13:00-17:00; Sat-Sun off.

## Resources

| Resource | Group |
| --- | --- |
| office manager | management |
| vice president | management |
| administrative assistant | office staff |
| intern | temp |
| caterer | outside service |
| technicians | outside service |
| printer | outside service |

## Schedule

| ID | WBS | Task | Type | Duration | Start | Finish | Predecessors | Baseline start | Baseline finish | Baseline duration | Total slack | Free slack | Resources | Work |
| --- | --- | --- | --- | --- | --- | --- | --- | --- | --- | --- | --- | --- | --- | --- |
| 1 | 1 | **Company Conference** |  | 25.62d | 2017-06-30 | 2017-08-04 |  | 2017-06-30 | 2017-08-04 | 25.62d | 0d |  |  | 560h |
| 2 | 1.1 | **Conference site** |  | 8d | 2017-06-30 | 2017-07-11 |  | 2017-06-30 | 2017-07-11 | 8d | 17.62d |  |  | 160h |
| 3 | 1.1.1 | Identify possible sites |  | 3d | 2017-06-30 | 2017-07-04 |  | 2017-06-30 | 2017-07-04 | 3d | 17.62d | 0d | administrative assistant | 24h |
| 4 | 1.1.2 | Visit sites |  | 1w | 2017-07-03 | 2017-07-07 | 3FS-2d | 2017-07-03 | 2017-07-07 | 1w | 17.62d | 0d | office manager; vice president; administrative assistant | 120h |
| 5 | 1.1.3 | Select site |  | 2d | 2017-07-10 | 2017-07-11 | 4 | 2017-07-10 | 2017-07-11 | 2d | 17.62d | 0d | office manager | 16h |
| 6 | 1.1.4 | Site selected | milestone | 0d | 2017-07-11 | 2017-07-11 | 5 | 2017-07-11 | 2017-07-11 | 0d | 17.62d |  |  |  |
| 7 | 1.2 | **Invitations** |  | 19.62d | 2017-06-30 | 2017-07-27 |  | 2017-06-30 | 2017-07-27 | 19.62d | 0d |  |  | 128h |
| 8 | 1.2.1 | Draft invitations |  | 1d | 2017-06-30 | 2017-06-30 |  | 2017-06-30 | 2017-06-30 | 1d | 0d |  | administrative assistant; intern | 16h |
| 9 | 1.2.2 | Print invitations |  | 1w | 2017-07-03 | 2017-07-07 | 8 | 2017-07-03 | 2017-07-07 | 1w | 0d |  | printer | 40h |
| 10 | 1.2.3 | Address invitations |  | 1w | 2017-07-10 | 2017-07-14 | 9 | 2017-07-10 | 2017-07-14 | 1w | 0d |  | intern | 40h |
| 11 | 1.2.4 | Send invitations |  | 2d | 2017-07-17 | 2017-07-18 | 10 | 2017-07-17 | 2017-07-18 | 2d | 0d |  | administrative assistant | 16h |
| 12 | 1.2.5 | Receive RSVPs |  | 1.5w | 2017-07-18 | 2017-07-27 | 11FS-1d | 2017-07-18 | 2017-07-27 | 1.5w | 0d |  | intern [25%] | 15h |
| 13 | 1.2.6 | Final count to caterer |  | 1h | 2017-07-27 | 2017-07-27 | 12 | 2017-07-27 | 2017-07-27 | 1h | 0d |  | administrative assistant | 1h |
| 14 | 1.2.7 | Invitations completed | milestone | 0d | 2017-07-27 | 2017-07-27 | 13 | 2017-07-27 | 2017-07-27 | 0d | 6d |  |  |  |
| 15 | 1.3 | **Food** |  | 18.62d | 2017-07-03 | 2017-07-27 |  | 2017-07-03 | 2017-07-27 | 18.62d | 0d |  |  | 160h |
| 16 | 1.3.1 | Interview caterers |  | 4d | 2017-07-03 | 2017-07-06 | 8SS+1d | 2017-07-03 | 2017-07-06 | 4d | 6.62d | 0d | vice president; office manager; administrative assistant | 96h |
| 17 | 1.3.2 | Hire caterer |  | 1d | 2017-07-10 | 2017-07-10 | 16FS+2.5% | 2017-07-10 | 2017-07-10 | 1d | 6.62d | 0d | office manager | 8h |
| 18 | 1.3.3 | Taste sample food |  | 1d | 2017-07-14 | 2017-07-14 | 17FS+3d | 2017-07-14 | 2017-07-14 | 1d | 6.62d | 0d | administrative assistant; caterer; office manager | 24h |
| 19 | 1.3.4 | Select final menu |  | 2d | 2017-07-17 | 2017-07-18 | 18 | 2017-07-17 | 2017-07-18 | 2d | 6.62d |  | office manager; administrative assistant | 32h |
| 20 | 1.3.5 | Food preparation complete | milestone | 0d | 2017-07-27 | 2017-07-27 | 19, 13 | 2017-07-27 | 2017-07-27 | 0d | 0d |  |  |  |
| 21 | 1.4 | **Speaker** |  | 5d | 2017-07-27 | 2017-08-03 | 15 | 2017-07-27 | 2017-08-03 | 5d | 0d |  |  | 112h |
| 22 | 1.4.1 | Interview speakers |  | 4d | 2017-07-27 | 2017-08-02 |  | 2017-07-27 | 2017-08-02 | 4d | 0d |  | office manager; administrative assistant; vice president | 96h |
| 23 | 1.4.2 | Hire keynote speaker |  | 0.5d | 2017-08-02 | 2017-08-03 | 22 | 2017-08-02 | 2017-08-03 | 0.5d | 0d |  | administrative assistant; office manager | 8h |
| 24 | 1.4.3 | Hire workshop facilitator |  | 0.5d | 2017-08-03 | 2017-08-03 | 23 | 2017-08-03 | 2017-08-03 | 0.5d | 0d |  | administrative assistant; office manager | 8h |
| 25 | 1.4.5 | Speakers selected | milestone | 0d | 2017-08-03 | 2017-08-03 | 24 | 2017-08-03 | 2017-08-03 | 0d | 0d |  |  |  |
| 26 | 1.5 | Day of conference | milestone | 0d | 2017-08-04 | 2017-08-04 | 21FS+1d | 2017-08-04 | 2017-08-04 | 0d | 0d |  |  |  |
