# Office Remodel

Schedule from MS Project, 2017-01-04 to 2017-02-10, status date 2017-01-31, costs in $, A marks actual dates.
Workspace
DCF

## Calendars

- Standard: Mon-Fri 08:00-12:00, 13:00-17:00; Sat-Sun off.

## Resources

| Resource | Group | Rate | Notes |
| --- | --- | --- | --- |
| Vice President | management | 38.46 |  |
| Office Manager | management | 25 |  |
| Administrative Assistant | office staff | 14.42 |  |
| Operations Manager | management | 21.63 |  |
| Space Planner | contract | 40 |  |
| Maintenance | maintenance | 16 | The cost rate table B is for construction cleaning tasks. |
| Contractor | contract |  |  |
| Mover | contract | 25 |  |
| Electrician | contract |  |  |
| Supervisor | office staff | 16.83 |  |

## Schedule

| ID | WBS | Task | Type | Duration | Start | Finish | Predecessors | Complete | Remaining | Baseline start | Baseline finish | Baseline duration | Total slack | Free slack | Constraint | Resources | Work | Cost | Baseline cost |
| --- | --- | --- | --- | --- | --- | --- | --- | --- | --- | --- | --- | --- | --- | --- | --- | --- | --- | --- | --- |
| 1 | 1 | **Office Workspace Remodel** |  | 27.5d | 2017-01-04 A | 2017-02-10 |  |  | 27.5d | 2017-01-04 | 2017-02-10 | 27.5d | 0d |  |  |  | 692h | 24,856.46 | 24,856.46 |
| 2 | 1.1 | **Space planning** |  | 11d | 2017-01-04 A | 2017-01-19 |  |  | 11d | 2017-01-04 | 2017-01-19 | 11d | 16.5d |  |  |  | 208h | 5,931.54 | 5,931.54 |
| 3 | 1.1.1 | Interview space planners |  | 0.8w | 2017-01-04 | 2017-01-09 |  |  |  | 2017-01-04 | 2017-01-09 | 0.8w | 7d | 0d |  | Operations Manager; Office Manager; Vice President [25%] | 72h | 1,800 | 1,800 |
| 4 | 1.1.2 | Hire space planner |  | 1d | 2017-01-10 | 2017-01-10 | 3 |  |  | 2017-01-10 | 2017-01-10 | 1d | 7d | 0d |  | Vice President; Administrative Assistant | 16h | 423.08 | 423.08 |
| 5 | 1.1.3 | Meeting w/space planner |  | 3d | 2017-01-11 | 2017-01-13 | 4 |  |  | 2017-01-11 | 2017-01-13 | 3d | 7d | 0d |  | Vice President; Administrative Assistant; Operations Manager; Space Planner | 96h | 2,748.46 | 2,748.46 |
| 6 | 1.1.4 | Finalize space plan |  | 3d | 2017-01-16 | 2017-01-18 | 5 |  |  | 2017-01-16 | 2017-01-18 | 3d | 16.5d |  |  | Space Planner | 24h | 960 | 960 |
| 7 | 1.1.5 | Space plan complete | milestone | 0d | 2017-01-19 A | 2017-01-19 A | 6 | 100% |  | 2017-01-19 | 2017-01-19 | 0d |  |  |  |  |  |  |  |
| 8 | 1.2 | **Furniture selection** |  | 13d | 2017-01-16 | 2017-02-02 |  |  |  | 2017-01-16 | 2017-02-02 | 13d | 6.5d |  |  |  | 68h | 1,407.69 | 1,407.69 |
| 9 | 1.2.1 | Preview furniture selections |  | 2.5d | 2017-01-16 | 2017-01-18 | 5 |  |  | 2017-01-16 | 2017-01-18 | 2.5d | 7d | 0d |  | Office Manager; Operations Manager; Administrative Assistant | 48h | 976.92 | 976.92 |
| 10 | 1.2.2 | Select new furniture |  | 2d | 2017-01-18 | 2017-01-20 | 9 |  |  | 2017-01-18 | 2017-01-20 | 2d | 7d | 0d |  | Office Manager [75%]; Operations Manager | 16h | 373.08 | 373.08 |
| 11 | 1.2.3 | Order new furniture |  | 0.5d | 2017-01-20 | 2017-01-20 | 10 |  |  | 2017-01-20 | 2017-01-20 | 0.5d | 7d | 0.5d |  | Administrative Assistant | 4h | 57.69 | 57.69 |
| 12 | 1.2.4 | Furniture delivered | milestone | 0d | 2017-02-02 | 2017-02-02 | 11FS+1.5w |  |  | 2017-02-02 | 2017-02-02 | 0d | 6.5d |  | start no earlier than 2017-02-02 |  |  |  |  |
| 13 | 1.3 | **Remodel workspace** |  | 13d | 2017-01-19 | 2017-02-06 |  |  |  | 2017-01-19 | 2017-02-06 | 13d | 0d |  |  |  | 280h | 14,423.08 | 14,423.08 |
| 14 | 1.3.1 | Hire contractor |  | 4d | 2017-01-19 | 2017-01-24 | 7 |  |  | 2017-01-19 | 2017-01-24 | 4d | 0d |  |  | Vice President; Operations Manager | 64h | 1,923.08 | 1,923.08 |
| 15 | 1.3.2 | Remodel workspace |  | 9d | 2017-01-25 | 2017-02-06 | 14 |  |  | 2017-01-25 | 2017-02-06 | 9d | 0d |  |  | Contractor [200%]; Electrician | 216h | 12,500 | 12,500 |
| 16 | 1.3.3 | Remodel complete | milestone | 0d | 2017-02-06 | 2017-02-06 | 15 |  |  | 2017-02-06 | 2017-02-06 | 0d | 3.5d |  |  |  |  |  |  |
| 17 | 1.4 | **New workspace** |  | 16.5d | 2017-01-19 | 2017-02-10 |  |  |  | 2017-01-19 | 2017-02-10 | 16.5d | 0d |  |  |  | 136h | 3,094.15 | 3,094.15 |
| 18 | 1.4.1 | Hire mover |  | 4d | 2017-01-19 | 2017-01-24 | 14SS |  |  | 2017-01-19 | 2017-01-24 | 4d | 6d | 0d |  | Supervisor | 32h | 538.46 | 538.46 |
| 19 | 1.4.2 | Pack workspace |  | 1d | 2017-01-25 | 2017-01-25 | 18, 14 |  |  | 2017-01-25 | 2017-01-25 | 1d | 6d | 0d |  | Administrative Assistant; Supervisor | 16h | 250 | 250 |
| 20 | 1.4.3 | Move Equipment |  | 0.5d | 2017-01-25 | 2017-01-25 | 19FF |  |  | 2017-01-25 | 2017-01-25 | 0.5d | 6d |  |  | Mover; Operations Manager | 8h | 186.54 | 186.54 |
| 21 | 1.4.4 | Remove existing furniture |  | 2d | 2017-02-03 | 2017-02-06 | 20 |  |  | 2017-02-03 | 2017-02-06 | 2d | 0d |  | as late as possible | Mover | 16h | 400 | 400 |
| 22 | 1.4.5 | Assemble new furniture |  | 2d | 2017-02-07 | 2017-02-08 | 21, 15 |  |  | 2017-02-07 | 2017-02-08 | 2d | 0d |  |  | Supervisor; Space Planner | 34h | 1,069.23 | 1,069.23 |
| 23 | 1.4.6 | Return equipment |  | 0.5d | 2017-02-08 | 2017-02-08 | 22FS-0.5d |  |  | 2017-02-08 | 2017-02-08 | 0.5d | 0d |  |  | Mover; Operations Manager | 8h | 186.54 | 186.54 |
| 24 | 1.4.7 | Unpack workspace |  | 1d | 2017-02-09 | 2017-02-09 | 23 |  |  | 2017-02-09 | 2017-02-09 | 1d | 0d |  |  | Mover; Administrative Assistant | 16h | 315.38 | 315.38 |
| 25 | 1.4.8 | Workspace final clean |  | 1d | 2017-02-09 | 2017-02-10 | 24FS-0.5d |  |  | 2017-02-09 | 2017-02-10 | 1d | 0d |  |  | Maintenance [50%]; Mover [50%] | 6h | 148 | 148 |
| 26 | 1.5 | Workspace remodel complete | milestone | 0d | 2017-02-10 | 2017-02-10 | 17 |  |  | 2017-02-10 | 2017-02-10 | 0d | 0d |  | finish no later than 2017-02-15 |  |  |  |  |

Notes:
- 11: Allow 1.5 weeks for delivery.
