# 2017 Meeting

Schedule from MS Project, 2017-06-05 to 2017-07-31, status date 2017-07-31, A marks actual dates.
Shareholders Meeting
DCF

## Calendars

- Standard: Mon-Fri 08:00-12:00, 13:00-17:00; Sat-Sun off.

## Resources

| Resource | Group |
| --- | --- |
| vice president | management |
| office manager | management |
| administrative assistant | office staff |
| intern | office staff |
| operations manager | management |

## Schedule

| ID | WBS | Task | Type | Duration | Start | Finish | Predecessors | Complete | Remaining | Baseline start | Baseline finish | Baseline duration | Total slack | Free slack | Resources | Work |
| --- | --- | --- | --- | --- | --- | --- | --- | --- | --- | --- | --- | --- | --- | --- | --- | --- |
| 1 | 1 | **Shareholders Meeting** |  | 39.62d | 2017-06-05 A | 2017-07-31 |  |  | 39.62d | 2017-06-05 | 2017-07-31 | 39.62d | 0d |  |  | 220h |
| 2 | 1.1 | **Plan meeting** |  | 36.62d | 2017-06-05 A | 2017-07-26 |  |  | 36.62d | 2017-06-05 | 2017-07-26 | 36.62d | 0d |  |  | 220h |
| 3 | 1.1.1 | **Preliminary planning** |  | 24d | 2017-06-05 A | 2017-07-07 |  |  | 24d | 2017-06-05 | 2017-07-07 | 24d | 0d |  |  | 108h |
| 4 | 1.1.1.1 | Schedule meeting date |  | 1d | 2017-06-05 | 2017-06-06 |  |  |  | 2017-06-05 | 2017-06-06 | 1d | 0d |  | vice president; office manager | 16h |
| 5 | 1.1.1.2 | Book conference center |  | 2d | 2017-06-07 | 2017-06-12 | 4 |  |  | 2017-06-07 | 2017-06-12 | 2d | 0d |  | intern | 16h |
| 6 | 1.1.1.3 | Book keynote speaker |  | 10d | 2017-06-12 | 2017-07-07 | 5FS-0.5d |  |  | 2017-06-12 | 2017-07-07 | 10d | 0d |  | office manager; administrative assistant | 76h |
| 7 | 1.1.1.4 | Preliminary planning complete | milestone | 0d | 2017-07-07 A | 2017-07-07 A | 6 | 100% |  | 2017-07-07 | 2017-07-07 | 0d |  |  |  |  |
| 8 | 1.1.2 | **Notification letter** |  | 7.62d | 2017-07-10 | 2017-07-20 | 3 |  |  | 2017-07-10 | 2017-07-20 | 7.62d | 0d |  |  | 36h |
| 9 | 1.1.2.1 | Order letter stock |  | 1h | 2017-07-10 | 2017-07-10 |  |  |  | 2017-07-10 | 2017-07-10 | 1h | 0d |  | intern | 1h |
| 10 | 1.1.2.2 | Develop letter |  | 1d | 2017-07-10 | 2017-07-12 | 9 |  |  | 2017-07-10 | 2017-07-12 | 1d | 0d |  | administrative assistant | 8h |
| 11 | 1.1.2.3 | Review letter |  | 1d | 2017-07-10 | 2017-07-12 | 10SS |  |  | 2017-07-10 | 2017-07-12 | 1d | 0d |  | office manager; operations manager | 11h |
| 12 | 1.1.2.4 | Approve letter |  | 1d | 2017-07-12 | 2017-07-14 | 11 |  |  | 2017-07-12 | 2017-07-14 | 1d | 4d | 0d | vice president | 8h |
| 13 | 1.1.2.5 | Print letter |  | 2d | 2017-07-14 | 2017-07-20 | 12 |  |  | 2017-07-14 | 2017-07-20 | 2d | 4d | 0d | intern [50%] | 8h |
| 14 | 1.1.2.6 | Send letter | milestone | 0d | 2017-07-20 | 2017-07-20 | 13 |  |  | 2017-07-20 | 2017-07-20 | 0d | 4d |  |  |  |
| 15 | 1.1.3 | **Meeting details** |  | 10d | 2017-07-12 | 2017-07-26 | 3 |  |  | 2017-07-12 | 2017-07-26 | 10d | 0d |  |  | 76h |
| 16 | 1.1.3.1 | Plan food with caterer |  | 3d | 2017-07-12 | 2017-07-20 | 11 |  |  | 2017-07-12 | 2017-07-20 | 3d | 0d |  | administrative assistant; office manager | 48h |
| 17 | 1.1.3.2 | Arrange committee meeting rooms |  | 0.5d | 2017-07-12 | 2017-07-13 | 16SS |  |  | 2017-07-12 | 2017-07-13 | 0.5d | 0d |  | intern | 4h |
| 18 | 1.1.3.3 | Arrange necessary equipment |  | 0.5d | 2017-07-13 | 2017-07-14 | 17 |  |  | 2017-07-13 | 2017-07-14 | 0.5d | 0d |  | intern | 4h |
| 19 | 1.1.3.4 | Create agenda |  | 3d | 2017-07-14 | 2017-07-24 | 18 |  |  | 2017-07-14 | 2017-07-24 | 3d | 0d |  | intern [50%] | 12h |
| 20 | 1.1.3.5 | Print agenda |  | 1d | 2017-07-24 | 2017-07-26 | 19 |  |  | 2017-07-24 | 2017-07-26 | 1d | 0d |  | intern | 8h |
| 21 | 1.2 | Meeting occurs! | milestone | 1d | 2017-07-28 | 2017-07-31 | 2FS+2d, 16, 17, 18, 20 |  |  | 2017-07-28 | 2017-07-31 | 1d | 0d |  |  |  |

Notes:
- 21: A Must Start On constraint should be set for the day of the Meeting.
