# 2017 Meeting

Schedule from MS Project, 2017-05-17 to 2017-06-15, status date 2017-05-27, A marks actual dates.
Shareholders Meeting
DCF

## Calendars

- Standard: Mon-Fri 08:00-12:00, 13:00-17:00; Sat-Sun off.

## Schedule

| ID | WBS | Task | Type | Duration | Start | Finish | Predecessors | Complete | Remaining | Baseline start | Baseline finish | Baseline duration | Total slack | Free slack |
| --- | --- | --- | --- | --- | --- | --- | --- | --- | --- | --- | --- | --- | --- | --- |
| 1 | 1 | **Shareholders Meeting** |  | 21.62d | 2017-05-17 A | 2017-06-15 |  |  | 21.62d | 2013-05-14 | 2013-06-12 | 21.62d | 0d |  |
| 2 | 1.1 | **Plan meeting** |  | 18.62d | 2017-05-17 A | 2017-06-12 |  |  | 18.62d | 2013-05-14 | 2013-06-07 | 18.62d | 0d |  |
| 3 | 1.1.1 | **Preliminary planning** |  | 12.5d | 2017-05-17 A | 2017-06-02 |  |  | 12.5d | 2013-05-14 | 2013-05-30 | 12.5d | 0d |  |
| 4 | 1.1.1.1 | Schedule meeting date |  | 1d | 2017-05-17 | 2017-05-17 |  |  |  | 2013-05-14 | 2013-05-14 | 1d | 0d |  |
| 5 | 1.1.1.2 | Book conference center |  | 2d | 2017-05-18 | 2017-05-19 | 4 |  |  | 2013-05-15 | 2013-05-16 | 2d | 0d |  |
| 6 | 1.1.1.3 | Book keynote speaker |  | 10d | 2017-05-19 | 2017-06-02 | 5FS-0.5d |  |  | 2013-05-16 | 2013-05-30 | 10d | 0d |  |
| 7 | 1.1.1.4 | Preliminary planning complete | milestone | 0d | 2017-06-02 A | 2017-06-02 A | 6 | 100% |  | 2013-05-30 | 2013-05-30 | 0d |  |  |
| 8 | 1.1.2 | **Notification letter** |  | 4.12d | 2017-06-02 | 2017-06-08 | 3 |  |  | 2013-05-30 | 2013-06-05 | 4.12d | 0d |  |
| 9 | 1.1.2.1 | Order letter stock |  | 1h | 2017-06-02 | 2017-06-02 |  |  |  | 2013-05-30 | 2013-05-30 | 1h | 0d |  |
| 10 | 1.1.2.2 | Develop letter |  | 1d | 2017-06-02 | 2017-06-05 | 9 |  |  | 2013-05-30 | 2013-05-31 | 1d | 0d |  |
| 11 | 1.1.2.3 | Review letter |  | 1d | 2017-06-02 | 2017-06-05 | 10SS |  |  | 2013-05-30 | 2013-05-31 | 1d | 0d |  |
| 12 | 1.1.2.4 | Approve letter |  | 1d | 2017-06-05 | 2017-06-06 | 11 |  |  | 2013-05-31 | 2013-06-03 | 1d | 2d | 0d |
| 13 | 1.1.2.5 | Print letter |  | 2d | 2017-06-06 | 2017-06-08 | 12 |  |  | 2013-06-03 | 2013-06-05 | 2d | 2d | 0d |
| 14 | 1.1.2.6 | Send letter | milestone | 0d | 2017-06-08 | 2017-06-08 | 13 |  |  | 2013-06-05 | 2013-06-05 | 0d | 2d |  |
| 15 | 1.1.3 | **Meeting details** |  | 5d | 2017-06-05 | 2017-06-12 | 3 |  |  | 2013-05-31 | 2013-06-07 | 5d | 0d |  |
| 16 | 1.1.3.1 | Plan food with caterer |  | 3d | 2017-06-05 | 2017-06-08 | 11 |  |  | 2013-05-31 | 2013-06-05 | 3d | 0d |  |
| 17 | 1.1.3.2 | Arrange committee meeting rooms |  | 0.5d | 2017-06-05 | 2017-06-06 | 16SS |  |  | 2013-05-31 | 2013-06-03 | 0.5d | 0d |  |
| 18 | 1.1.3.3 | Arrange necessary equipment |  | 0.5d | 2017-06-06 | 2017-06-06 | 17 |  |  | 2013-06-03 | 2013-06-03 | 0.5d | 0d |  |
| 19 | 1.1.3.4 | Create agenda |  | 3d | 2017-06-06 | 2017-06-09 | 18 |  |  | 2013-06-03 | 2013-06-06 | 3d | 0d |  |
| 20 | 1.1.3.5 | Print agenda |  | 1d | 2017-06-09 | 2017-06-12 | 19 |  |  | 2013-06-06 | 2013-06-07 | 1d | 0d |  |
| 21 | 1.2 | Meeting occurs! | milestone | 1d | 2017-06-14 | 2017-06-15 | 2FS+2d, 16, 17, 18, 20 |  |  | 2013-06-11 | 2013-06-12 | 1d | 0d |  |

Notes:
- 21: A Must Start On constraint should be set for the day of the Meeting.
